# pla_suivi1

Schedule from MS Project, 2002-10-21 to 2002-12-05, A marks actual dates.
sans

## Calendars

- Standard: Mon-Fri 08:00-12:00, 13:00-17:00; Sat-Sun off.

## Resources

| Resource |
| --- |
| RVI |
| FBI |
| LMA |
| ABA |

## Schedule

| ID | WBS | Task | Duration | Start | Finish | Predecessors | Complete | Remaining | Baseline start | Baseline finish | Baseline duration | Total slack | Free slack | Constraint | Resources | Work | Actual work |
| --- | --- | --- | --- | --- | --- | --- | --- | --- | --- | --- | --- | --- | --- | --- | --- | --- | --- |
| 2 | 1 | **Produit OEDL** | 32.5d? | 2002-10-21 A | 2002-12-04 |  | 22% | 25.47d? | 2002-10-21 | 2002-11-29 | 30d? | 1.5d |  |  |  | 1132h | 148h |
| 3 | 1.1 | **IHM** | 5d? | 2002-10-21 A | 2002-10-25 A |  | 100% |  | 2002-10-21 | 2002-10-25 | 5d? |  |  |  |  | 28h | 28h |
| 4 | 1.1.1 | Codage IHM Eval | 1.5d? | 2002-10-21 A | 2002-10-22 A |  | 100% |  | 2002-10-21 | 2002-10-22 | 1.5d? |  |  | start no earlier than 2002-10-21 | RVI | 12h | 12h |
| 5 | 1.1.2 | Intégration des IHM | 2d? | 2002-10-24 A | 2002-10-25 A | 4 | 100% |  | 2002-10-24 | 2002-10-25 | 2d? |  |  | start no earlier than 2002-10-24 | FBI | 16h | 16h |
| 6 | 1.2 | **CVS** | 15d? | 2002-10-21 A | 2002-11-08 |  | 50% | 7.5d? | 2002-11-04 | 2002-11-08 | 5d? | 19d |  |  |  | 80h | 40h |
| 7 | 1.2.1 | Etude CVS | 5d? | 2002-10-21 A | 2002-10-25 A |  | 100% |  |  |  |  |  |  | start no earlier than 2002-10-21 | RVI | 40h | 40h |
| 8 | 1.2.2 | Installation CVS | 4d | 2002-11-04 | 2002-11-07 |  |  |  | 2002-11-04 | 2002-11-07 | 4d | 19d | 0d | start no earlier than 2002-11-04 | FBI | 32h |  |
| 9 | 1.2.3 | Mettre le projet sur CVS | 1d? | 2002-11-08 | 2002-11-08 | 8 |  |  | 2002-11-08 | 2002-11-08 | 1d? | 19d |  |  | FBI | 8h |  |
| 10 | 1.3 | **Management du développement** | 28d? | 2002-10-21 A | 2002-11-27 |  | 43% | 15.83d? | 2002-10-21 | 2002-11-27 | 28d? | 6d |  |  |  | 228h | 40h |
| 11 | 1.3.1 | Processus de management + fichier excel | 4d? | 2002-10-21 A | 2002-10-24 A |  | 100% |  | 2002-10-21 | 2002-10-24 | 4d? |  |  | start no earlier than 2002-10-21 | ABA | 32h | 32h |
| 12 | 1.3.2 | Vérification du processus | 1d? | 2002-10-25 A | 2002-10-25 A | 11 | 100% |  | 2002-10-25 | 2002-10-25 | 1d? |  |  | start no earlier than 2002-10-25 | LMA | 8h | 8h |
| 13 | 1.3.3 | Rédaction intial | 2.5d? | 2002-11-04 | 2002-11-06 | 12 |  |  | 2002-11-04 | 2002-11-06 | 2.5d? | 17.5d | 0d | start no earlier than 2002-11-04 | RVI; FBI; LMA | 60h |  |
| 14 | 1.3.4 | Suivi | 1d? | 2002-11-06 | 2002-11-07 | 13 |  |  | 2002-11-06 | 2002-11-07 | 1d? | 17.5d | 3.5d |  | RVI; FBI; LMA; ABA | 32h |  |
| 15 | 1.3.5 | Suivi | 1d? | 2002-11-13 | 2002-11-13 | 14 |  |  | 2002-11-13 | 2002-11-13 | 1d? | 14d | 4d | start no earlier than 2002-11-13 | RVI; FBI; LMA; ABA | 32h |  |
| 16 | 1.3.6 | Suivi | 1d? | 2002-11-20 | 2002-11-20 | 15 |  |  | 2002-11-20 | 2002-11-20 | 1d? | 10d | 4d | start no earlier than 2002-11-20 | RVI; FBI; LMA; ABA | 32h |  |
| 17 | 1.3.7 | Suivi | 1d? | 2002-11-27 | 2002-11-27 | 16 |  |  | 2002-11-27 | 2002-11-27 | 1d? | 6d |  | start no earlier than 2002-11-27 | RVI; FBI; LMA; ABA | 32h |  |
| 18 | 1.4 | **Mise aux normes** | 5d? | 2002-10-21 | 2002-10-25 |  |  |  | 2002-10-21 | 2002-10-25 | 5d? | 29d |  |  |  | 80h |  |
| 19 | 1.4.1 | Mise à la norme prototype admin | 5d? | 2002-10-21 | 2002-10-25 |  |  |  | 2002-10-21 | 2002-10-25 | 5d? | 29d |  | start no earlier than 2002-10-21 | FBI | 40h |  |
| 20 | 1.4.2 | Mise à la norme prototype eval | 5d? | 2002-10-21 | 2002-10-25 |  |  |  | 2002-10-21 | 2002-10-25 | 5d? | 29d |  | start no earlier than 2002-10-21 | RVI | 40h |  |
| 21 | 1.5 | **Codage** | 15d? | 2002-11-04 | 2002-11-22 |  |  |  | 2002-11-04 | 2002-11-22 | 15d? | 9d |  |  |  | 344h |  |
| 22 | 1.5.1 | Réintégration - Revue | 2d? | 2002-11-04 | 2002-11-05 |  |  |  | 2002-11-04 | 2002-11-05 | 2d? | 22d |  | start no earlier than 2002-11-04 | LMA | 16h |  |
| 23 | 1.5.2 | Définition d'un système de message d'erreur | 5d? | 2002-11-04 | 2002-11-08 |  |  |  | 2002-11-04 | 2002-11-08 | 5d? | 19d |  | start no earlier than 2002-11-04 | FBI | 40h |  |
| 24 | 1.5.3 | Codage des classes | 2d? | 2002-11-07 | 2002-11-08 |  |  |  | 2002-11-07 | 2002-11-08 | 2d? | 9d | 0d |  | FBI; LMA; RVI | 48h |  |
| 25 | 1.5.4 | Codage des classes | 5d? | 2002-11-11 | 2002-11-15 | 24 |  |  | 2002-11-11 | 2002-11-15 | 5d? | 9d | 0d |  | FBI; LMA; RVI | 120h |  |
| 26 | 1.5.5 | Codage des classes | 5d? | 2002-11-18 | 2002-11-22 | 25 |  |  | 2002-11-18 | 2002-11-22 | 5d? | 9d |  |  | FBI; LMA; RVI | 120h |  |

| ID | WBS | Task | Duration | Start | Finish | Predecessors | Complete | Remaining | Baseline start | Baseline finish | Baseline duration | Total slack | Free slack | Constraint | Resources | Work | Actual work |
| --- | --- | --- | --- | --- | --- | --- | --- | --- | --- | --- | --- | --- | --- | --- | --- | --- | --- |
| 27 | 1.6 | **Déploiement** | 5d? | 2002-11-25 | 2002-11-29 |  |  |  | 2002-11-25 | 2002-11-29 | 5d? | 4d |  |  |  | 40h |  |
| 28 | 1.6.1 | Ecriture script sql d init de la BD | 5d? | 2002-11-25 | 2002-11-29 |  |  |  | 2002-11-25 | 2002-11-29 | 5d? | 4d |  | start no earlier than 2002-11-25 | RVI | 40h |  |
| 29 | 1.7 | **Intégration** | 5d? | 2002-11-25 | 2002-11-29 |  |  |  | 2002-11-25 | 2002-11-29 | 5d? | 4d |  |  |  | 232h |  |
| 30 | 1.7.1 | Intégration Admin | 2d? | 2002-11-25 | 2002-11-26 |  |  |  | 2002-11-25 | 2002-11-26 | 2d? | 4d | 0d | start no earlier than 2002-11-25 | FBI | 16h |  |
| 31 | 1.7.2 | Intégration Eval | 2d? | 2002-11-25 | 2002-11-26 |  |  |  | 2002-11-25 | 2002-11-26 | 2d? | 4d | 0d | start no earlier than 2002-11-25 | RVI | 16h |  |
| 32 | 1.7.3 | Intégration OT | 2d? | 2002-11-25 | 2002-11-26 |  |  |  | 2002-11-25 | 2002-11-26 | 2d? | 4d | 0d | start no earlier than 2002-11-25 | LMA | 16h |  |
| 33 | 1.7.4 | Intégration des 3 modules | 3d? | 2002-11-27 | 2002-11-29 | 32, 31, 30 |  |  | 2002-11-27 | 2002-11-29 | 3d? | 4d |  |  | LMA; ABA; FBI; RVI | 96h |  |
| 34 | 1.7.5 | Effectuer tests d'intégration | 2d? | 2002-11-28 | 2002-11-29 |  |  |  | 2002-11-28 | 2002-11-29 | 2d? | 4d |  | start no earlier than 2002-11-28 | LMA; ABA; FBI; RVI | 64h |  |
| 35 | 1.7.6 | Corection des bugs Admin | 1d? | 2002-11-29 | 2002-11-29 |  |  |  | 2002-11-29 | 2002-11-29 | 1d? | 4d |  | start no earlier than 2002-11-29 | FBI | 8h |  |
| 36 | 1.7.7 | Correction des bugs Eval | 1d? | 2002-11-29 | 2002-11-29 |  |  |  | 2002-11-29 | 2002-11-29 | 1d? | 4d |  | start no earlier than 2002-11-29 | RVI | 8h |  |
| 37 | 1.7.8 | Correction des bugs OT | 1d? | 2002-11-29 | 2002-11-29 |  |  |  | 2002-11-29 | 2002-11-29 | 1d? | 4d |  | start no earlier than 2002-11-29 | LMA | 8h |  |
| 38 | 1.8 | **Tests fonctionnels** | 2.5d? | 2002-12-02 | 2002-12-04 |  |  |  |  |  |  | 1.5d |  |  |  | 60h |  |
| 39 | 1.8.1 | Correction des bugs Admin | 2.5d? | 2002-12-02 | 2002-12-04 |  |  |  |  |  |  | 1.5d |  | start no earlier than 2002-12-02 | FBI | 20h |  |
| 40 | 1.8.2 | Correction des bugs Eval | 2.5d? | 2002-12-02 | 2002-12-04 |  |  |  |  |  |  | 1.5d |  | start no earlier than 2002-12-02 | RVI | 20h |  |
| 41 | 1.8.3 | Correction des bugs OT | 2.5d? | 2002-12-02 | 2002-12-04 |  |  |  |  |  |  | 1.5d |  | start no earlier than 2002-12-02 | LMA | 20h |  |
| 42 | 1.9 | **Etude tests** | 5d? | 2002-10-21 A | 2002-10-25 A |  | 100% |  |  |  |  |  |  |  |  | 40h | 40h |
| 43 | 1.9.1 | etude automatisation des tests | 5d? | 2002-10-21 A | 2002-10-25 A |  | 100% |  |  |  |  |  |  | start no earlier than 2002-10-21 | LMA | 40h | 40h |
| 46 | 2 | **Manuel Utilisateur** | 34d? | 2002-10-21 A | 2002-12-05 |  | 20% | 27.2d? |  |  |  | 0d |  |  |  | 184h | 40h |
| 47 | 2.1 | Etude norme 1063 | 5d? | 2002-10-21 A | 2002-10-25 A |  | 100% |  |  |  |  |  |  | start no earlier than 2002-10-21 | RVI | 40h | 40h |
| 48 | 2.2 | Mise en évidence du processus de remplissage | 1d? | 2002-11-13 | 2002-11-13 | 47 |  |  |  |  |  | 2d |  | start no earlier than 2002-11-13 | RVI; FBI; LMA; ABA | 32h |  |
| 49 | 2.3 | Rédaction | 5d? | 2002-11-18 | 2002-11-22 | 48 |  |  |  |  |  | 0d |  | start no earlier than 2002-11-18 |  |  |  |
| 50 | 2.4 | Rédaction | 5d? | 2002-11-25 | 2002-11-29 | 49 |  |  |  |  |  | 0d |  |  | ABA | 40h |  |
| 51 | 2.5 | Rédaction | 2d? | 2002-12-02 | 2002-12-03 | 50 |  |  |  |  |  | 0d |  |  | ABA | 16h |  |
| 52 | 2.6 | Etude initialisation | 2.5d? | 2002-11-25 | 2002-11-27 |  |  |  |  |  |  | 6.5d |  | start no earlier than 2002-11-25 | FBI | 20h |  |
| 53 | 2.7 | etude installation | 2.5d? | 2002-11-25 | 2002-11-27 |  |  |  |  |  |  | 6.5d |  | start no earlier than 2002-11-25 | LMA | 20h |  |
| 54 | 2.8 | Verification | 1d? | 2002-12-04 | 2002-12-04 | 51 |  |  |  |  |  | 0d |  | start no earlier than 2002-12-04 | LMA | 8h |  |
| 55 | 2.9 | Validation | 1d? | 2002-12-05 | 2002-12-05 | 54 |  |  |  |  |  | 0d |  |  | ABA | 8h |  |

| ID | WBS | Task | Duration | Start | Finish | Predecessors | Complete | Remaining | Total slack | Free slack | Constraint | Resources | Work | Actual work |
| --- | --- | --- | --- | --- | --- | --- | --- | --- | --- | --- | --- | --- | --- | --- |
| 57 | 3 | **Framework Junit** | 20d? | 2002-10-21 A | 2002-11-15 |  | 50% | 10d? | 14d |  |  |  | 80h | 40h |
| 58 | 3.1 | Etude sur methode de tests | 5d? | 2002-10-21 A | 2002-10-25 A |  | 100% |  |  |  | start no earlier than 2002-10-21 | LMA | 40h | 40h |
| 59 | 3.2 | Junit methode de test | 5d? | 2002-11-11 | 2002-11-15 |  |  |  | 14d |  | start no earlier than 2002-11-11 | LMA | 40h |  |
| 61 | 4 | **CR des tests de validation** | 18.5d? | 2002-11-11 | 2002-12-05 |  |  |  | 0.5d |  |  |  | 168h |  |
| 62 | 4.1 | **Scenarios de tests** | 15d? | 2002-11-11 | 2002-11-29 |  |  |  | 4d |  |  |  | 120h |  |
| 63 | 4.1.1 | Correction du PTV d apres remarques CCH | 1d? | 2002-11-11 | 2002-11-11 |  |  |  | 4d | 0d | start no earlier than 2002-11-11 | RVI | 8h |  |
| 64 | 4.1.2 | Rédaction 10 scenarios | 4d? | 2002-11-12 | 2002-11-15 | 63 |  |  | 4d | 0d |  | ABA | 32h |  |
| 65 | 4.1.3 | Rédaction 10 scenarios | 5d? | 2002-11-18 | 2002-11-22 | 64 |  |  | 4d | 0d |  | ABA | 40h |  |
| 66 | 4.1.4 | Rédaction 15 scenarios | 5d? | 2002-11-25 | 2002-11-29 | 65 |  |  | 4d |  |  | ABA | 40h |  |
| 67 | 4.2 | **Test** | 2.5d? | 2002-12-02 | 2002-12-04 |  |  |  | 0.5d |  |  |  | 40h |  |
| 68 | 4.2.1 | Effectuer les tests des scenarios | 1.5d? | 2002-12-02 | 2002-12-03 |  |  |  | 0.5d | 0d | start no earlier than 2002-12-02 | ABA; LMA | 24h |  |
| 69 | 4.2.2 | Remplir les fiches | 1d? | 2002-12-03 | 2002-12-04 | 68 |  |  | 0.5d | 0d | start no earlier than 2002-12-03 | FBI; RVI | 16h |  |
| 70 | 4.3 | **Document** | 1d? | 2002-12-04 | 2002-12-05 |  |  |  | 0.5d |  |  |  | 8h |  |
| 71 | 4.3.1 | Rédaction | 1d? | 2002-12-04 | 2002-12-05 | 69 |  |  | 0.5d |  | start no earlier than 2002-12-04 | ABA | 8h |  |
| 73 | 5 | **Présentation Soutenance** | 1d? | 2002-12-03 | 2002-12-03 |  |  |  | 2d |  |  |  | 16h |  |
| 74 | 5.1 | préparation BD | 1d? | 2002-12-03 | 2002-12-03 |  |  |  | 2d |  | start no earlier than 2002-12-03 | RVI | 8h |  |
| 75 | 5.2 | préparation- install logiciel OEDL | 1d? | 2002-12-03 | 2002-12-03 |  |  |  | 2d |  | start no earlier than 2002-12-03 | LMA | 8h |  |
